# طرح تولید محصول میکروبی ازدیاد برداشت مخازن نفت خام با قابلیت حذف باکتری‌های SRB و کاهش H2S مخزن

Schedule from MS Project, 2020-10-05 to 2023-07-04, costs in €.

## Calendars

- Standard: Mon-Fri 08:00-12:00, 13:00-17:00; Sat-Sun off.

## Schedule

| ID | WBS | Task | Duration | Start | Finish | Predecessors | Total slack | Free slack | Cost | ـارخ شروع (شمسی) | تاریخ پایان (شمسی) | Text1 |
| --- | --- | --- | --- | --- | --- | --- | --- | --- | --- | --- | --- | --- |
| 1 | 1 | **فاز مطالعاتی** | 44d | 2020-10-05 | 2020-12-03 |  | 575d | 0d | 5 | 1399/7/14 | 1399/9/13 |  |
| 2 | 1.1 | **بررسی مطالعاتی** | 44d | 2020-10-05 | 2020-12-03 |  | 575d |  | 5 | 1399/7/14 | 1399/9/13 |  |
| 3 | 1.1.1 | جستجوی منابع | 22d | 2020-10-05 | 2020-11-03 |  | 575d | 0d | 5 | 1399/7/14 | 1399/8/13 | 6000 |
| 4 | 1.1.2 | ترجمه و گردآوری | 22d | 2020-11-04 | 2020-12-03 | 3 | 575d |  |  | 1399/8/14 | 1399/9/13 | 9000 |
| 5 | 2 | **طراحی فرمولاسیون محصول میکروبی ازدیاد برداشت مخازن نفت خام با قابلیت حذف باکتری‌های SRB و کاهش H2S مخزن** | 98d | 2020-12-04 | 2021-04-20 | 1 | 575d |  |  | 1399/9/14 | 1400/1/31 |  |
| 6 | 2.1 | **طراحی فرمولاسیون** | 44d | 2020-12-04 | 2021-02-03 |  | 575d | 0d |  | 1399/9/14 | 1399/11/15 |  |
| 7 | 2.1.1 | طراحی آزمایش آماری | 22d | 2020-12-04 | 2021-01-04 |  | 575d | 0d |  | 1399/9/14 | 1399/10/15 | 3000 |
| 8 | 2.1.2 | انجام آزمایش¬های بهینه سازی | 22d | 2021-01-05 | 2021-02-03 | 7 | 575d |  |  | 1399/10/16 | 1399/11/15 | 15000 |
| 9 | 2.2 | **ساخت نمونه آزمایشگاهی** | 22d | 2021-02-04 | 2021-03-05 | 6 | 575d | 0d |  | 1399/11/16 | 1399/12/15 |  |
| 10 | 2.2.1 | تأمین مواد اولیه و وسایل | 5d | 2021-02-04 | 2021-02-10 |  | 575d | 0d |  | 1399/11/16 | 1399/11/22 | 3000 |
| 11 | 2.2.2 | فرایند تولید نمونه آزمایشگاهی | 10d | 2021-02-11 | 2021-02-24 | 10 | 575d | 0d |  | 1399/11/23 | 1399/12/6 | 15000 |
| 12 | 2.2.3 | تست خصوصیات محصول | 7d | 2021-02-25 | 2021-03-05 | 11 | 575d |  |  | 1399/12/7 | 1399/12/15 | 9000 |
| 13 | 2.3 | **آزمون کنترل کیفی** | 32d | 2021-03-08 | 2021-04-20 | 9 | 575d |  |  | 1399/12/18 | 1400/1/31 |  |
| 14 | 2.3.1 | آزمون اثر باکتری¬کشی بر روی سویه های باکتری SRB | 10d | 2021-03-08 | 2021-03-19 |  | 575d | 0d |  | 1399/12/18 | 1399/12/29 |  |
| 15 | 2.3.2 | آزمون مقاومت دمایی | 7d | 2021-03-22 | 2021-03-30 | 14 | 575d | 0d |  | 1400/1/2 | 1400/1/10 | 9000 |
| 16 | 2.3.3 | آزمون مقاونت شوری | 7d | 2021-03-31 | 2021-04-08 | 15 | 575d | 0d |  | 1400/1/11 | 1400/1/19 | 9000 |
| 17 | 2.3.4 | آزمون مقاومت pH | 8d | 2021-04-09 | 2021-04-20 | 16 | 575d |  |  | 1400/1/20 | 1400/1/31 | 9000 |
| 18 | 3 | **تولید نیمه صنعتی محصول** | 169d | 2020-10-05 | 2021-05-27 |  | 0d |  |  | 1399/7/14 | 1400/3/6 |  |
| 19 | 3.1 | **بهینه سازی فرایند تولید صنعتی** | 15d | 2020-10-05 | 2020-10-23 |  | 0d |  |  | 1399/7/14 | 1399/8/2 | 15000 |
| 20 | 3.1.1 | بهینه سازی محیط کشت تکثیری و تولیدی | 15d | 2020-10-05 | 2020-10-23 |  | 0d |  |  | 1399/7/14 | 1399/8/2 |  |
| 21 | 3.1.2 | بهینه سازی هوادهی | 15d | 2020-10-05 | 2020-10-23 |  | 0d |  |  | 1399/7/14 | 1399/8/2 |  |
| 22 | 3.2 | **اجرای عملیات تولید نیمه¬صنعتی محصول** | 154d | 2020-10-26 | 2021-05-27 | 19 | 0d |  |  | 1399/8/5 | 1400/3/6 |  |
| 23 | 3.2.1 | تأمین مواد مصرفی | 22d | 2020-10-26 | 2020-11-24 |  | 0d |  |  | 1399/8/5 | 1399/9/4 | 15000 |
| 24 | 3.2.2 | عملیات تولید در فرمانتور صنعتی | 88d | 2020-11-25 | 2021-03-26 | 23 | 0d |  |  | 1399/9/5 | 1400/1/6 | 30000 |
| 25 | 3.2.3 | اجرای عملیات بلندینگ | 22d | 2021-03-29 | 2021-04-27 | 24 | 0d |  |  | 1400/1/9 | 1400/2/7 | 6000 |
| 26 | 3.2.4 | فرایندهای پایین دستی | 22d | 2021-04-28 | 2021-05-27 | 23, 24, 25 | 0d |  |  | 1400/2/8 | 1400/3/6 | 9000 |

Notes:
- 1: Text4: گزارش فازمطالعاتی
- 5: Text4: دانش فنی فرمولاسیون محصول؛ نمونه آزمایشگاهی محصول؛ نتایج آزمون مقاومت محصول نسبت به دما، شوری و pH؛ نتایج اثر ضدمیکروبی محصول بر روی سویه های باکتری SRB جدا شده از آب تزریقی سیری
- 19: Text4: شرایط بهینه کشت و تولید محصول در فرمانتور نیمه صنعتی شامل نوع محیط کشت تکثیر باکتری، نوع محیط کشت تولید محصول و میزان بهینه هوادهی؛ تولید 200 لیتر نمونه نیمه صنعتی محصول

| ID | WBS | Task | Duration | Start | Finish | Predecessors | Total slack | ـارخ شروع (شمسی) | تاریخ پایان (شمسی) | Text1 | Text4 |
| --- | --- | --- | --- | --- | --- | --- | --- | --- | --- | --- | --- |
| 27 | 4 | **آزمون عملکرد محصول در شرایط واقعی** | 518d | 2021-05-28 | 2023-05-23 | 18 | 0d | 1400/3/7 | 1402/3/2 |  |  |
| 28 | 4.1 | آزمون حذف باکتریهای احیا کننده گوگرد در مقیاس پایلوت آزمایشگاهی | 120d | 2021-05-28 | 2021-11-11 |  | 398d | 1400/3/7 | 1400/8/20 | 30000 |  |
| 29 | 4.2 | **آزمون مغزه** | 518d | 2021-05-28 | 2023-05-23 |  | 0d | 1400/3/7 | 1402/3/2 |  |  |
| 30 | 4.2.1 | تأمین و انتقال تجهیزات، مواد و وسایل | 60d | 2021-05-28 | 2021-08-19 |  | 0d | 1400/3/7 | 1400/5/28 | 15000 |  |
| 31 | 4.2.2 | اجرای عملیات تست مغزه | 458d | 2021-08-20 | 2023-05-23 | 30 | 0d | 1400/5/29 | 1402/3/2 | 15000 |  |
| 32 | 5 | **گزارش پایانی** | 30d | 2023-05-24 | 2023-07-04 | 27 | 0d | 1402/3/3 | 1402/4/13 |  | گزارش پایانی |
| 33 | 5.1 | گردآوری داده¬ها | 15d | 2023-05-24 | 2023-06-13 |  | 0d | 1402/3/3 | 1402/3/23 | 6000 |  |
| 34 | 5.2 | تدوین و ارائه گزارش پایانی | 15d | 2023-06-14 | 2023-07-04 | 33 | 0d | 1402/3/24 | 1402/4/13 | 6000 |  |
| 35 | 5.3 | برگزاری دوره آموزشی | 30d | 2023-05-24 | 2023-07-04 |  | 0d | 1402/3/3 | 1402/4/13 | 6000 |  |
